# Software Development

Schedule from MS Project, 2008-01-08 to 2008-04-15, costs in $.

## Calendars

- Standard: Mon-Fri 08:00-12:00, 13:00-17:00; Sat-Sun off.

## Resources

| Resource | Rate |
| --- | --- |
| Carlos Perez | 40 |
| Lazaro Pi | 40 |
| Meng Shi | 40 |
| David Villegas | 40 |
| Yudiesly Herrera | 40 |

## Schedule

| ID | WBS | Task | Type | Duration | Start | Finish | Predecessors | Total slack | Free slack | Constraint | Resources | Work | Cost |
| --- | --- | --- | --- | --- | --- | --- | --- | --- | --- | --- | --- | --- | --- |
| 1 | 1 | **Scope** |  | 7d | 2008-01-08 | 2008-01-16 |  | 14.45d |  |  |  | 116.67h | 4,666.67 |
| 2 | 1.1 | Determine project scope |  | 1h | 2008-01-08 | 2008-01-08 |  | 70.88d |  | start no earlier than 2008-01-08 |  |  |  |
| 3 | 1.2 | Determine project members |  | 1h | 2008-01-08 | 2008-01-08 |  | 14.45d | 0d | start no earlier than 2008-01-08 |  |  |  |
| 4 | 1.3 | Define preliminary resources |  | 1.25d | 2008-01-08 | 2008-01-09 | 3 | 14.45d | 0.62d |  | Carlos Perez [20%]; David Villegas [20%]; Lazaro Pi [20%]; Meng Shi [20%]; Yudiesly Herrera [20%] | 10h | 400 |
| 5 | 1.4 | Study resources |  | 5d | 2008-01-10 | 2008-01-16 | 4 | 13.82d | 0d | start no earlier than 2008-01-10 | Carlos Perez [62.7%]; David Villegas; Lazaro Pi; Meng Shi; Yudiesly Herrera [62.7%] | 106.67h | 4,266.67 |
| 6 | 1.5 | Scope complete | milestone | 0d | 2008-01-16 | 2008-01-16 | 5 | 13.82d | 0d | start no earlier than 2008-01-14 |  |  |  |
| 7 | 2 | **Requirements and Analysis** |  | 25.33d | 2008-01-17 | 2008-02-21 | 6 | 13.82d |  |  |  | 357.4h | 14,296 |
| 8 | 2.1 | Conduct needs analysis |  | 1d | 2008-01-17 | 2008-01-17 |  | 63d |  | start no earlier than 2008-01-15 | Carlos Perez [20%]; David Villegas [20%]; Lazaro Pi [20%]; Meng Shi [20%]; Yudiesly Herrera [20%] | 8h | 384 |
| 9 | 2.2 | Draft preliminary software specifications |  | 1d | 2008-01-17 | 2008-01-17 |  | 46.29d | 0d | start no earlier than 2008-01-17 | Carlos Perez [20%]; David Villegas [20%]; Lazaro Pi [20%]; Meng Shi [20%]; Yudiesly Herrera [20%] | 8h | 256 |
| 10 | 2.3 | Review software specifications with team |  | 2h | 2008-01-18 | 2008-01-18 | 9 | 46.29d | 0d | start no earlier than 2008-01-18 | Carlos Perez; David Villegas; Lazaro Pi; Meng Shi; Yudiesly Herrera | 10h | 400 |
| 11 | 2.4 | Incorporate feedback on software specifications |  | 1h | 2008-01-18 | 2008-01-18 | 10 | 46.29d | 0d |  | Carlos Perez; David Villegas; Lazaro Pi; Meng Shi; Yudiesly Herrera | 5h | 200 |
| 12 | 2.5 | Use Cases |  | 7d | 2008-01-18 | 2008-01-29 | 11 | 46.29d | 0d |  | Lazaro Pi [30%]; Carlos Perez [15%]; David Villegas [15%]; Meng Shi [15%]; Yudiesly Herrera [15%] | 50.4h | 2,016 |
| 13 | 2.6 | Project Feasibility |  | 10d | 2008-01-31 | 2008-02-13 |  | 44d |  | finish no earlier than 2008-02-13 | Carlos Perez [50%]; Yudiesly Herrera [50%] | 80h | 3,200 |
| 14 | 2.7 | Scenarios |  | 9.33d | 2008-01-29 | 2008-02-11 | 12 | 46.29d |  |  | Carlos Perez [15%]; David Villegas [15%]; Lazaro Pi [30%]; Meng Shi [15%]; Yudiesly Herrera [15%] | 56h | 2,240 |
| 15 | 2.8 | Dynamic Models |  | 6.67d | 2008-01-29 | 2008-02-07 | 12 | 48.96d |  |  | Lazaro Pi [30%]; Carlos Perez [15%]; David Villegas [15%]; Meng Shi [15%]; Yudiesly Herrera [15%] | 40h | 1,600 |
| 16 | 2.9 | Static Models |  | 5d | 2008-02-05 | 2008-02-11 |  | 0.82d | 0d | start no earlier than 2008-02-05 | Lazaro Pi [30%]; Carlos Perez [15%]; David Villegas [15%]; Meng Shi [15%]; Yudiesly Herrera [15%] | 36h | 1,440 |
| 17 | 2.10 | User Interface |  | 5.33d | 2008-02-12 | 2008-02-19 | 16 | 0.82d | 0d |  | Lazaro Pi [50%]; Carlos Perez [50%] | 32h | 1,280 |
| 18 | 2.11 | Document Assembly |  | 2d | 2008-02-19 | 2008-02-21 | 17 | 0.82d | 0d | start no earlier than 2008-02-14 | David Villegas; Meng Shi | 32h | 1,280 |
| 19 | 2.12 | Analysis complete | milestone | 0d | 2008-02-21 | 2008-02-21 | 18 | 0.82d | 0d | start no earlier than 2008-02-18 |  |  |  |
| 20 | 3 | **Architecture and Design** |  | 23.47d | 2008-02-21 | 2008-03-25 | 19 | 0.82d | 0d |  |  | 260.96h | 10,438.4 |
| 21 | 3.1 | **Architecture and Design** |  | 14d | 2008-02-21 | 2008-03-12 |  | 0.82d | 0d |  |  | 142.67h | 5,706.67 |
| 22 | 3.1.1 | Architecture Design and Style |  | 7d | 2008-02-21 | 2008-03-03 |  | 0.82d | 0d | start no earlier than 2008-02-20 | Carlos Perez [50%]; Yudiesly Herrera [50%] | 56h | 2,240 |
| 23 | 3.1.2 | Refined Class Diagram |  | 7d | 2008-03-03 | 2008-03-12 | 22 | 0.82d |  |  | Carlos Perez [20%]; David Villegas [60%]; Yudiesly Herrera [20%] | 56h | 2,240 |
| 24 | 3.1.3 | Package Diagram |  | 3.83d | 2008-03-03 | 2008-03-07 | 22 | 3.99d |  |  | Meng Shi [50%]; Lazaro Pi [20%]; Yudiesly Herrera [30%] | 30.67h | 1,226.67 |

| ID | WBS | Task | Type | Duration | Start | Finish | Predecessors | Total slack | Free slack | Constraint | Resources | Work | Cost |
| --- | --- | --- | --- | --- | --- | --- | --- | --- | --- | --- | --- | --- | --- |
| 25 | 3.2 | **Refined Dynamic Models** |  | 7.47d | 2008-03-12 | 2008-03-21 | 21 | 0.82d |  |  |  | 102.29h | 4,091.73 |
| 26 | 3.2.1 | Sequence Diagrams |  | 7.47d | 2008-03-12 | 2008-03-21 | 22 | 0.82d | 0d | start no earlier than 2008-02-20 | Lazaro Pi [70%]; Carlos Perez [10%] | 46.29h | 1,851.73 |
| 27 | 3.2.2 | Activity Diagrams |  | 7.47d | 2008-03-12 | 2008-03-21 | 22 | 2.83d |  |  | Meng Shi [75%]; David Villegas [25%] | 56h | 2,240 |
| 28 | 3.3 | **Refined User Interface** |  | 2d | 2008-03-21 | 2008-03-25 | 26 | 0.82d | 0d |  |  | 16h | 640 |
| 29 | 3.3.1 | Windows |  | 1d | 2008-03-21 | 2008-03-24 |  | 0.82d | 0d | start no earlier than 2008-02-20 | Lazaro Pi | 8h | 320 |
| 30 | 3.3.2 | Menu |  | 5h | 2008-03-24 | 2008-03-25 | 29 | 0.82d | 0d |  | David Villegas | 5h | 200 |
| 31 | 3.3.3 | Dialog |  | 3h | 2008-03-25 | 2008-03-25 | 30 | 0.82d |  |  | Carlos Perez | 3h | 120 |
| 32 | 3.4 | Design complete | milestone | 0d | 2008-03-25 | 2008-03-25 | 28 | 0.82d | 0d | start no earlier than 2008-03-25 |  |  |  |
| 33 | 4 | **Implementation and Testing** |  | 14d | 2008-03-25 | 2008-04-14 | 32 | 0.82d |  |  |  | 644h | 25,760 |
| 34 | 4.1 | Test Plan |  | 1d | 2008-03-26 | 2008-03-26 |  | 8d | 0d | start no earlier than 2008-03-26 | Meng Shi | 8h | 320 |
| 35 | 4.2 | **Functional Testing** |  | 3d | 2008-03-27 | 2008-03-31 | 34 | 11d |  |  | David Villegas | 24h | 960 |
| 36 | 4.2.1 | Test Data Design |  | 2d | 2008-03-27 | 2008-03-28 |  | 11d | 0d |  |  |  |  |
| 37 | 4.2.2 | Test Cases (Input and Expected Data Results) |  | 1d | 2008-03-31 | 2008-03-31 | 36 | 11d |  |  |  |  |  |
| 38 | 4.3 | **Structural Testing** |  | 3d | 2008-03-27 | 2008-03-31 | 34 | 11d |  |  | Meng Shi | 24h | 960 |
| 39 | 4.3.1 | Coverage Criteria |  | 2d | 2008-03-27 | 2008-03-28 |  | 11d | 0d |  |  |  |  |
| 40 | 4.3.2 | Test Cases (Input and Expected Data Results) |  | 1d | 2008-03-31 | 2008-03-31 | 39 | 11d |  |  |  |  |  |
| 41 | 4.4 | **Integration Testing** |  | 6d | 2008-03-27 | 2008-04-03 | 34 | 8d |  |  | Yudiesly Herrera [70%]; David Villegas [40%] | 52.8h | 2,112 |
| 42 | 4.4.1 | Integration Strategies |  | 3d | 2008-03-27 | 2008-03-31 |  | 8d | 0d |  |  |  |  |
| 43 | 4.4.2 | Test drivers and stubs |  | 1d | 2008-04-01 | 2008-04-01 | 42 | 8d | 0d |  |  |  |  |
| 44 | 4.4.3 | Test Cases (Input and Expected Data Results) |  | 2d | 2008-04-02 | 2008-04-03 | 43 | 8d |  |  |  |  |  |
| 45 | 4.5 | **System Testing** |  | 1d | 2008-03-27 | 2008-03-27 | 34 | 13d |  |  | Carlos Perez | 8h | 320 |
| 46 | 4.5.1 | Test Cases |  | 1d | 2008-03-27 | 2008-03-27 |  | 13d |  |  |  |  |  |
| 47 | 4.6 | Implementation |  | 13d | 2008-03-25 | 2008-04-11 | 20 | 0.82d | 0d |  | Carlos Perez; David Villegas; Lazaro Pi; Meng Shi; Yudiesly Herrera | 499.2h | 19,968 |
| 48 | 4.7 | Actual Functional Testing Results |  | 1d | 2008-04-11 | 2008-04-14 | 47 | 1.2d |  |  | Yudiesly Herrera | 8h | 320 |
| 49 | 4.8 | Actual Structural Testing Results |  | 1d | 2008-04-11 | 2008-04-14 | 47 | 1.2d |  |  | Meng Shi | 8h | 320 |
| 50 | 4.9 | Actual Integration Testing Results |  | 1d | 2008-04-11 | 2008-04-14 | 47 | 1.2d |  |  | David Villegas | 8h | 320 |
| 51 | 4.10 | Actual System Testing |  | 4h | 2008-04-11 | 2008-04-14 | 47 | 1.7d | 0d |  | Carlos Perez | 4h | 160 |
| 52 | 4.11 | Implementation and Testing Complete | milestone | 0d | 2008-04-14 | 2008-04-14 | 51 | 1.7d |  | finish no earlier than 2008-04-11 |  |  |  |

| ID | WBS | Task | Type | Duration | Start | Finish | Predecessors | Total slack | Free slack | Constraint |
| --- | --- | --- | --- | --- | --- | --- | --- | --- | --- | --- |
| 53 | 5 | **Deployment and Installation** |  | 2.2d | 2008-04-11 | 2008-04-15 | 47 | 0d |  |  |
| 54 | 5.1 | Determine final deployment strategy |  | 1d | 2008-04-11 | 2008-04-14 |  | 0.82d | 0d | start no earlier than 2008-04-11 |
| 55 | 5.2 | Secure deployment resources |  | 2h | 2008-04-14 | 2008-04-15 | 54 | 0.82d | 0d |  |
| 56 | 5.3 | Deploy software |  | 1h | 2008-04-15 | 2008-04-15 | 55 | 0.82d |  |  |
| 57 | 5.4 | Deployment complete | milestone | 0d | 2008-04-15 | 2008-04-15 | 56 | 0d |  | finish no earlier than 2008-04-15 |
